# BESIIIv8

Schedule from MS Project, 2003-01-01 to 2008-09-01, status date 2004-06-14, A marks actual dates.
IHEP

## Calendars

- Standard: Mon-Fri 08:00-12:00, 13:00-17:00; Sat-Sun off.

## Resources

| Resource |
| --- |
| Sr. Software Engineer |
| Physicist-Programmer |
| Physicist |
| Computing Specialist |
| Data Aid |

## Schedule

| ID | WBS | Task | Duration | Start | Finish | Complete | Remaining | Baseline start | Baseline finish | Baseline duration | Total slack | Free slack | Constraint | Deadline | Text1 |
| --- | --- | --- | --- | --- | --- | --- | --- | --- | --- | --- | --- | --- | --- | --- | --- |
| 1 | 1 | **Computing** | 1479d? | 2003-01-01 A | 2008-09-01 | 21% | 1163.42d? |  |  |  | 0d |  |  |  |  |
| 2 | 1.1 | **Computing Coordination/Management** | 697d? | 2004-06-01 A | 2007-01-31 | 9% | 631.4d? |  |  |  | 413d |  |  |  | 李卫东/冒亚军 |
| 3 | 1.1.1 | **Milestones** | 687d? | 2004-06-15 | 2007-01-31 |  |  | 2003-09-10 | 2006-10-02 | 798d | 413d |  |  |  |  |
| 4 | 1.1.1.1 | Migation to Gaudi | 45d? | 2004-06-15 | 2004-08-16 |  |  | 2004-04-01 | 2004-04-01 | 0d | 1055d |  | finish no earlier than 2004-08-16 |  |  |
| 5 | 1.1.1.2 | BOSS Alpha Release | 66d? | 2004-10-01 | 2004-12-31 |  |  |  |  |  | 956d |  | start no earlier than 2004-10-01 |  |  |
| 6 | 1.1.1.3 | Physics Analysis Starts | 21d? | 2005-10-03 | 2005-10-31 |  |  |  |  |  | 740d |  | start no earlier than 2005-10-03 |  |  |
| 7 | 1.1.1.4 | BOSS Betta Release | 43d? | 2005-09-01 | 2005-10-31 |  |  |  |  |  | 740d |  | start no earlier than 2005-09-01 |  |  |
| 8 | 1.1.1.5 | Data Challenge | 260d | 2006-01-02 | 2006-12-29 |  |  | 2004-11-30 | 2004-11-30 | 0d | 436d |  | finish no earlier than 2006-12-29 |  |  |
| 9 | 1.1.1.6 | Computing TDR Released | 65d | 2005-10-03 | 2005-12-30 |  |  | 2005-06-30 | 2005-06-30 | 0d | 696d |  | finish no earlier than 2005-12-30 |  |  |
| 10 | 1.1.1.7 | BOSS Production Release | 65d? | 2006-10-02 | 2006-12-29 |  |  |  |  |  | 436d |  | finish no earlier than 2006-12-29 |  |  |
| 11 | 1.1.1.8 | Ready for Cosmic Rays | 22d | 2007-01-02 | 2007-01-31 |  |  | 2006-10-02 | 2006-10-02 | 0d | 413d |  | finish no earlier than 2007-01-31 |  |  |
| 12 | 1.1.2 | Planning and Resources Coordination | 674d | 2004-06-01 A | 2006-12-29 | 1% | 664d |  |  |  | 436d |  | finish no earlier than 2006-12-29 |  |  |
| 13 | 1.1.3 | **Releases** | 413d | 2004-09-01 A | 2006-03-31 | 74% | 106.87d |  |  |  | 631d |  |  |  |  |
| 14 | 1.1.3.1 | **Release 3.0** | 22d | 2004-09-01 | 2004-09-30 |  |  |  |  |  | -265d | 0d |  |  |  |
| 15 | 1.1.3.1.1 | Builds | 11d | 2004-09-01 | 2004-09-15 |  |  |  |  |  | -265d | 0d | finish no earlier than 2004-09-15 | 2003-09-10 |  |
| 16 | 1.1.3.1.2 | Testing | 19d | 2004-09-06 | 2004-09-30 |  |  |  |  |  | 1022d |  | finish no earlier than 2004-09-30 |  |  |
| 17 | 1.1.3.2 | **Release 4.0** | 23d | 2004-12-01 | 2004-12-31 |  |  |  |  |  | 956d |  |  |  |  |
| 18 | 1.1.3.2.1 | Builds | 11d | 2004-12-01 | 2004-12-15 |  |  |  |  |  | 968d |  | start no earlier than 2004-12-01 |  |  |
| 19 | 1.1.3.2.2 | Testing | 18d | 2004-12-08 | 2004-12-31 |  |  |  |  |  | 956d |  | start no earlier than 2004-12-08 |  |  |
| 20 | 1.1.3.3 | **Release 5.0** | 23d | 2005-03-01 A | 2005-03-31 A | 100% |  |  |  |  |  |  |  |  |  |
| 21 | 1.1.3.3.1 | Builds | 11d | 2005-03-01 A | 2005-03-15 A | 100% |  |  |  |  |  |  |  |  |  |
| 22 | 1.1.3.3.2 | Testing | 18d | 2005-03-08 A | 2005-03-31 A | 100% |  |  |  |  |  |  |  |  |  |
| 23 | 1.1.3.4 | **Release 6.0** | 22d | 2005-06-01 A | 2005-06-30 A | 100% |  |  |  |  |  |  |  |  |  |
| 24 | 1.1.3.4.1 | Builds | 11d | 2005-06-01 A | 2005-06-15 A | 100% |  |  |  |  |  |  |  |  |  |
| 25 | 1.1.3.4.2 | Testing | 17d | 2005-06-08 A | 2005-06-30 A | 100% |  |  |  |  |  |  |  |  |  |

| ID | WBS | Task | Duration | Start | Finish | Complete | Remaining | Total slack | Constraint | Text1 |
| --- | --- | --- | --- | --- | --- | --- | --- | --- | --- | --- |
| 26 | 1.1.3.5 | **Release 7.0** | 43d | 2005-09-01 A | 2005-10-31 A | 100% |  |  |  |  |
| 27 | 1.1.3.5.1 | Builds | 22d | 2005-09-01 A | 2005-09-30 A | 100% |  |  |  |  |
| 28 | 1.1.3.5.2 | Testing | 33d | 2005-09-15 A | 2005-10-31 A | 100% |  |  |  |  |
| 29 | 1.1.3.6 | **Release 8.0** | 22d | 2005-12-01 A | 2005-12-30 A | 100% |  |  |  |  |
| 30 | 1.1.3.6.1 | Builds | 11d | 2005-12-01 A | 2005-12-15 A | 100% |  |  |  |  |
| 31 | 1.1.3.6.2 | Testing | 17d | 2005-12-08 A | 2005-12-30 A | 100% |  |  |  |  |
| 32 | 1.1.3.7 | **Release 9.0** | 23d | 2006-03-01 A | 2006-03-31 A | 100% |  |  |  |  |
| 33 | 1.1.3.7.1 | Builds | 11d | 2006-03-01 A | 2006-03-15 A | 100% |  |  |  |  |
| 34 | 1.1.3.7.2 | Testing | 18d | 2006-03-08 A | 2006-03-31 A | 100% |  |  |  |  |
| 35 | 1.1.4 | **Computing TDR** | 153d | 2005-06-01 | 2005-12-30 |  |  | 696d |  |  |
| 36 | 1.1.4.1 | Collect Information | 1.1mo | 2005-06-01 | 2005-06-30 |  |  | 827d | finish no earlier than 2005-06-30 |  |
| 37 | 1.1.4.2 | Write Draft 1 | 8.8w | 2005-07-01 | 2005-08-31 |  |  | 783d | finish no earlier than 2005-08-31 |  |
| 38 | 1.1.4.3 | Comment Period | 1.1mo | 2005-09-01 | 2005-09-30 |  |  | 761d | finish no earlier than 2005-09-30 |  |
| 39 | 1.1.4.4 | Write Final Draft | 13w | 2005-10-03 | 2005-12-30 |  |  | 696d | finish no earlier than 2005-12-30 |  |
| 40 | 1.1.5 | Coordination in Computing Environment | 260d? | 2006-01-02 | 2006-12-29 |  |  | 436d | start no earlier than 2006-01-02 |  |
| 41 | 1.2 | **Software Project** | 1479d? | 2003-01-01 A | 2008-09-01 | 22% | 1147.21d? | 0d |  |  |
| 42 | 1.2.1 | **Framework and Analysis Core Software** | 390d? | 2004-01-02 A | 2005-06-30 | 20% | 311.84d? | 827d |  |  |
| 43 | 1.2.1.1 | Coordination/Management | 1d? | 2004-06-14 A | 2004-06-14 A | 100% |  |  | finish no earlier than 2004-06-14 | 李卫东/冒亚军 |
| 44 | 1.2.1.2 | **Event Data Model (EDM)** | 66d? | 2004-07-01 A | 2004-09-30 | 27% | 48d? | 1022d |  |  |
| 45 | 1.2.1.2.1 | **Event Data Model for raw data** | 22d? | 2004-07-01 | 2004-07-30 |  |  | 1066d |  | 李卫东 |
| 46 | 1.2.1.2.1.1 | MDC Raw Data EDM | 22d? | 2004-07-01 | 2004-07-30 |  |  | 1066d | start no earlier than 2004-07-01 | 臧石磊 |
| 47 | 1.2.1.2.1.2 | TOF Raw Data EDM | 22d? | 2004-07-01 | 2004-07-30 |  |  | 1066d | start no earlier than 2004-07-01 | 蒋林立 |
| 48 | 1.2.1.2.1.3 | EMC Raw Data EDM | 22d? | 2004-07-01 | 2004-07-30 |  |  | 1066d | start no earlier than 2004-07-01 | 王喆 |
| 49 | 1.2.1.2.1.4 | Muon Counter Raw Data EDM | 22d? | 2004-07-01 | 2004-07-30 |  |  | 1066d | start no earlier than 2004-07-01 | 北大 |

| ID | WBS | Task | Duration | Start | Finish | Complete | Remaining | Total slack | Constraint | Text1 |
| --- | --- | --- | --- | --- | --- | --- | --- | --- | --- | --- |
| 50 | 1.2.1.2.2 | **EDM for Reconstructed Data** | 22d? | 2004-08-02 | 2004-08-31 |  |  | 1044d |  | 李卫东 |
| 51 | 1.2.1.2.2.1 | MDC Reconstructed Data EDM | 22d? | 2004-08-02 | 2004-08-31 |  |  | 1044d | start no earlier than 2004-08-02 | 臧石磊 |
| 52 | 1.2.1.2.2.2 | TOF Reconstructed Data EDM | 22d? | 2004-08-02 | 2004-08-31 |  |  | 1044d | start no earlier than 2004-08-02 | 蒋林立 |
| 53 | 1.2.1.2.2.3 | EMC Reconstructed Data EDM | 22d? | 2004-08-02 | 2004-08-31 |  |  | 1044d | start no earlier than 2004-08-02 | 王喆 |
| 54 | 1.2.1.2.2.4 | Muon Counter Reconstructed Data EDM | 22d? | 2004-08-02 | 2004-08-31 |  |  | 1044d | start no earlier than 2004-08-02 | 北大 |
| 55 | 1.2.1.2.3 | EDM for M.C. truth information | 22d? | 2004-09-01 A | 2004-09-30 A | 100% |  |  | finish no earlier than 2004-06-14 |  |
| 56 | 1.2.1.2.4 | Event Data Object Navigation | 44d? | 2004-08-02 A | 2004-09-30 A | 100% |  |  | finish no earlier than 2004-06-14 |  |
| 57 | 1.2.1.3 | **Event Format** | 261d? | 2004-06-01 | 2005-05-31 |  |  | 849d |  |  |
| 58 | 1.2.1.3.1 | Raw Data Event | 44d? | 2004-06-01 | 2004-07-30 |  |  | 1066d | start no earlier than 2004-06-01 | 张晓梅 |
| 59 | 1.2.1.3.2 | DST Data Event | 261d? | 2004-06-01 | 2005-05-31 |  |  | 849d | finish no earlier than 2005-05-31 | 山大 |
| 60 | 1.2.1.3.3 | Root Event | 261d? | 2004-06-01 | 2005-05-31 |  |  | 849d | finish no earlier than 2005-05-31 | 山大 |
| 61 | 1.2.1.4 | **Detector Description** | 110d? | 2004-06-01 | 2004-11-01 |  |  | 1000d |  |  |
| 62 | 1.2.1.4.1 | Detector identifier | 23d? | 2004-06-15 | 2004-07-15 |  |  | 1077d | finish no earlier than 2004-07-15 | 李卫东 |
| 63 | 1.2.1.4.2 | MDC Geometry Information Service | 22d? | 2004-07-01 | 2004-07-30 |  |  | 1066d | finish no earlier than 2004-07-30 | 臧石磊 |
| 64 | 1.2.1.4.3 | TOF Geometry Information Service | 22d? | 2004-07-01 | 2004-07-30 |  |  | 1066d | start no earlier than 2004-07-01 | 蒋林立 |
| 65 | 1.2.1.4.4 | EMC Geometry Information Service | 22d? | 2004-07-01 | 2004-07-30 |  |  | 1066d | start no earlier than 2004-07-01 | 王喆 |
| 66 | 1.2.1.4.5 | Muon Counter Information Service | 22d? | 2004-07-01 | 2004-07-30 |  |  | 1066d | start no earlier than 2004-07-01 | 北大 |
| 67 | 1.2.1.4.6 | ROOT Detector Description | 110d? | 2004-06-01 | 2004-11-01 |  |  | 1000d |  | 北大 |
| 68 | 1.2.1.5 | **Event Data Conversion Service** | 261d? | 2004-06-01 A | 2005-05-31 | 51% | 127.77d? | 849d |  |  |
| 69 | 1.2.1.5.1 | Common Event Data Input/Output Utility | 22d? | 2004-06-01 A | 2004-06-30 A | 100% |  |  | finish no earlier than 2004-06-14 | 李卫东 |
| 70 | 1.2.1.5.2 | ASCII format Raw Data Conversion Service | 44d? | 2004-06-01 A | 2004-07-30 | 90% | 4.4d? | 1066d | finish no earlier than 2004-06-14 | 李卫东 |
| 71 | 1.2.1.5.3 | Byte Stream Raw Data Conversion Service | 44d? | 2004-06-01 | 2004-07-30 |  |  | 1066d | start no earlier than 2004-06-01 | 张晓梅 |
| 72 | 1.2.1.5.4 | ROOT Event Conversion Service | 261d? | 2004-06-01 | 2005-05-31 |  |  | 849d | finish no earlier than 2005-05-31 | 山大 |
| 73 | 1.2.1.5.5 | DST Data Conversion Service | 261d? | 2004-06-01 A | 2005-05-31 A | 100% |  |  | finish no earlier than 2004-06-14 | 山大 |

| ID | WBS | Task | Duration | Start | Finish | Complete | Remaining | Baseline start | Baseline finish | Baseline duration | Total slack | Constraint | Text1 |
| --- | --- | --- | --- | --- | --- | --- | --- | --- | --- | --- | --- | --- | --- |
| 74 | 1.2.1.6 | **Event Display** | 239d? | 2004-08-02 | 2005-06-30 |  |  |  |  |  | 827d |  |  |
| 75 | 1.2.1.6.1 | Graphics User Interface | 44d? | 2004-08-02 | 2004-09-30 |  |  |  |  |  | 1022d | start no earlier than 2004-08-02 | 郑直 |
| 76 | 1.2.1.6.2 | Detector Display | 88d? | 2004-09-01 | 2004-12-31 |  |  |  |  |  | 956d | finish no earlier than 2004-12-31 | 郑直 |
| 77 | 1.2.1.6.3 | Event Data Display | 129d? | 2005-01-03 | 2005-06-30 |  |  |  |  |  | 827d | finish no earlier than 2005-06-30 | 郑直 |
| 78 | 1.2.1.7 | Event Pileup Service | 129d | 2005-01-03 | 2005-06-30 |  |  |  |  |  | 827d | finish no earlier than 2005-06-30 | 山大 |
| 79 | 1.2.1.8 | **Physics Analysis Tools** | 390d? | 2004-01-02 A | 2005-06-30 | 29% | 275.67d? |  |  |  | 827d |  |  |
| 80 | 1.2.1.8.1 | Kinematics Fitting | 107d? | 2004-01-02 A | 2004-05-31 A | 100% |  |  |  |  |  | finish no earlier than 2004-05-31 | 山大 |
| 81 | 1.2.1.8.2 | Particle Identifying | 129d? | 2005-01-03 | 2005-06-30 |  |  |  |  |  | 827d | finish no earlier than 2005-06-30 |  |
| 82 | 1.2.1.8.3 | Secondary Vertex Finding | 129d? | 2005-01-03 | 2005-06-30 |  |  |  |  |  | 827d | finish no earlier than 2005-06-30 | 山大 |
| 83 | 1.2.1.9 | **Utilities** | 21d? | 2004-10-01 | 2004-10-29 |  |  |  |  |  | 1001d |  |  |
| 84 | 1.2.1.9.1 | Timing measurement tool | 21d? | 2004-10-01 | 2004-10-29 |  |  |  |  |  | 1001d | finish no earlier than 2004-10-29 | 李卫东 |
| 85 | 1.2.1.10 | Integration of Simulation with BOSS framework | 45d? | 2004-11-01 A | 2004-12-31 | 2% | 44d? |  |  |  | 956d | finish no earlier than 2004-12-31 | 李卫东 |
| 86 | 1.2.2 | **Simulation Software** | 1479d? | 2003-01-01 A | 2008-09-01 | 1% | 1469.41d? | 2004-01-02 | 2005-06-30 | 390d? | 0d |  |  |
| 87 | 1.2.2.1 | Coordination/Management | 1d? | 2004-06-14 A | 2004-06-14 A | 100% |  | 2004-06-14 | 2004-06-14 | 1d? |  | finish no earlier than 2004-06-14 | 刘怀民 |
| 88 | 1.2.2.2 | **Simulation Framework** | 913d? | 2003-01-01 | 2006-06-30 |  |  | 2004-06-01 | 2004-12-30 | 153d? | 566d |  |  |
| 89 | 1.2.2.2.1 | Framework Design | 153d? | 2003-01-01 | 2003-08-01 |  |  | 2004-06-01 | 2004-07-30 | 44d? | 1326d | start no earlier than 2003-01-01 | 刘怀民 |
| 90 | 1.2.2.2.2 | Code Management | 652d? | 2004-01-01 | 2006-06-30 |  |  | 2004-06-01 | 2004-12-30 | 153d? | 566d | finish no earlier than 2006-06-30 | 邓子艳 |
| 91 | 1.2.2.2.3 | Integration to BOSS | 88d? | 2004-10-01 | 2005-02-01 |  |  | 2004-06-01 | 2004-09-30 | 88d? | 934d | start no earlier than 2004-10-01 | 邓子艳 |
| 92 | 1.2.2.3 | **Event Generator** | 317d? | 2003-06-02 | 2004-08-17 |  |  | 2004-06-01 | 2004-07-30 | 44d? | 1054d |  |  |
| 93 | 1.2.2.3.1 | **GENBES - BESII Event Generator Package** | 79d? | 2004-04-29 | 2004-08-17 |  |  | 2004-07-01 | 2004-07-30 | 22d? | 1054d |  | 刘怀民 |
| 94 | 1.2.2.3.1.1 | Data Structure in HEPEVT | 77d? | 2004-04-29 | 2004-08-15 |  |  | 2004-07-01 | 2004-07-30 | 22d? | 1056d | finish no earlier than 2004-08-15 | 刘怀民 |
| 95 | 1.2.2.3.1.2 | Event I/O in ASCII File | 77d? | 2004-05-03 | 2004-08-17 |  |  | 2004-07-01 | 2004-07-30 | 22d? | 1054d | start no earlier than 2004-05-01 | 刘怀民 |
| 96 | 1.2.2.3.1.3 | Interface with BOOST | 77d? | 2004-04-29 | 2004-08-15 |  |  | 2004-07-01 | 2004-07-30 | 22d? | 1056d | finish no earlier than 2004-08-15 | 刘怀民 |
| 97 | 1.2.2.3.2 | TESTER - Simple Event Generator | 22d? | 2003-06-02 | 2003-07-01 |  |  | 2004-06-01 | 2004-06-30 | 22d? | 1349d | start no earlier than 2003-06-01 | 刘怀民 |

| ID | WBS | Task | Duration | Start | Finish | Predecessors | Baseline start | Baseline finish | Baseline duration | Total slack | Free slack | Constraint | Text1 |
| --- | --- | --- | --- | --- | --- | --- | --- | --- | --- | --- | --- | --- | --- |
| 98 | 1.2.2.4 | **Detector Description** | 64d? | 2004-12-01 | 2005-02-28 |  | 2004-06-01 | 2004-11-01 | 110d? | 915d |  |  |  |
| 99 | 1.2.2.4.1 | Geometry Description with XML | 64d? | 2004-12-01 | 2005-02-28 |  | 2004-06-15 | 2004-07-15 | 23d? | 915d |  | finish no earlier than 2005-02-28 | 北大 |
| 100 | 1.2.2.4.2 | Material Description with XML | 64d? | 2004-12-01 | 2005-02-28 |  | 2004-07-01 | 2004-07-30 | 22d? | 915d |  | finish no earlier than 2005-02-28 | 刘怀民 |
| 101 | 1.2.2.5 | **MDC Simulation** | 371d? | 2003-12-30 | 2005-05-31 |  | 2004-06-01 | 2004-11-01 | 110d? | 849d |  |  |  |
| 102 | 1.2.2.5.1 | Geometry Description | 176d? | 2003-12-30 | 2004-08-31 |  | 2004-06-15 | 2004-07-15 | 23d? | 1044d |  | finish no earlier than 2004-08-31 | 袁野 |
| 103 | 1.2.2.5.2 | Hit Information | 176d? | 2003-12-30 | 2004-08-31 |  | 2004-07-01 | 2004-07-30 | 22d? | 1044d |  | finish no earlier than 2004-08-31 | 袁野 |
| 104 | 1.2.2.5.3 | Simple Digitization | 176d? | 2003-12-30 | 2004-08-31 |  | 2004-07-01 | 2004-07-30 | 22d? | 1044d |  | finish no earlier than 2004-08-31 | 袁野 |
| 105 | 1.2.2.5.4 | Real Digitization | 219d? | 2004-07-29 | 2005-05-31 |  | 2004-07-01 | 2004-07-30 | 22d? | 849d |  | finish no earlier than 2005-05-31 | 袁野 |
| 106 | 1.2.2.6 | **TOF Simulation** | 545d? | 2003-04-30 | 2005-05-31 |  | 2004-06-01 | 2004-11-01 | 110d? | 849d |  |  |  |
| 107 | 1.2.2.6.1 | Geometry Description | 176d? | 2003-04-30 | 2003-12-31 |  | 2004-06-15 | 2004-07-15 | 23d? | 1218d |  | finish no earlier than 2003-12-31 | 邓子艳 |
| 108 | 1.2.2.6.2 | Hit Information | 109d? | 2003-08-01 | 2003-12-31 |  | 2004-07-01 | 2004-07-30 | 22d? | 1153d | 0d | finish no earlier than 2003-12-31 | 邓子艳 |
| 109 | 1.2.2.6.3 | Simple Digitization | 65d? | 2004-01-01 | 2004-03-31 | 108 | 2004-07-01 | 2004-07-30 | 22d? | 1153d |  | finish no earlier than 2004-03-31 | 邓子艳 |
| 110 | 1.2.2.6.4 | Real Digitization | 219d? | 2004-07-29 | 2005-05-31 |  | 2004-07-01 | 2004-07-30 | 22d? | 849d |  | finish no earlier than 2005-05-31 | 邓子艳 |
| 111 | 1.2.2.7 | **EMC Simulation** | 371d? | 2004-01-01 | 2005-06-02 |  | 2004-06-01 | 2004-11-01 | 110d? | 847d |  |  |  |
| 112 | 1.2.2.7.1 | Geometry Description | 142d? | 2004-01-01 | 2004-07-16 |  | 2004-06-15 | 2004-07-15 | 23d? | 1076d |  | start no earlier than 2004-01-01 | 付成栋/何苗 |
| 113 | 1.2.2.7.2 | Hit Information | 111d? | 2004-03-01 | 2004-08-02 |  | 2004-07-01 | 2004-07-30 | 22d? | 1065d |  | start no earlier than 2004-03-01 | 付成栋/何苗 |
| 114 | 1.2.2.7.3 | Simple Digitization | 22d? | 2004-07-01 | 2004-07-30 |  | 2004-07-01 | 2004-07-30 | 22d? | 847d | 0d | start no earlier than 2004-07-01 | 付成栋/何苗 |
| 115 | 1.2.2.7.4 | Real Digitization | 219d? | 2004-08-02 | 2005-06-02 | 114 | 2004-07-01 | 2004-07-30 | 22d? | 847d |  | finish no earlier than 2005-05-31 | 付成栋/何苗 |
| 116 | 1.2.2.8 | **MUC Simulation** | 435d? | 2003-10-01 | 2005-05-31 |  | 2004-06-01 | 2004-11-01 | 110d? | 849d |  |  |  |
| 117 | 1.2.2.8.1 | Geometry Description | 66d? | 2003-10-01 | 2003-12-31 |  | 2004-06-15 | 2004-07-15 | 23d? | 1175d | 0d | finish no earlier than 2003-12-31 | 北大 |
| 118 | 1.2.2.8.2 | Hit Information | 43d? | 2004-01-01 | 2004-03-01 | 117 | 2004-07-01 | 2004-07-30 | 22d? | 1175d |  | start no earlier than 2004-01-01 | 北大 |
| 119 | 1.2.2.8.3 | Simple Digitization | 43d? | 2003-12-31 | 2004-02-28 |  | 2004-07-01 | 2004-07-30 | 22d? | 1176d |  | finish no earlier than 2004-02-28 | 北大 |
| 120 | 1.2.2.8.4 | Real Digitization | 219d? | 2004-07-29 | 2005-05-31 |  | 2004-07-01 | 2004-07-30 | 22d? | 849d |  | finish no earlier than 2005-05-31 | 北大 |
| 121 | 1.2.2.9 | **Common Detector Parts** | 501d? | 2003-05-01 | 2005-03-31 |  | 2004-06-01 | 2004-11-01 | 110d? | 892d |  |  |  |
| 122 | 1.2.2.9.1 | Beam pipe | 22d? | 2003-05-01 | 2003-05-31 |  | 2004-06-15 | 2004-07-15 | 23d? | 1371d |  | finish no earlier than 2003-05-31 | 刘怀民 |
| 123 | 1.2.2.9.2 | Magnetic coil | 22d? | 2004-07-01 | 2004-07-30 |  | 2004-07-01 | 2004-07-30 | 22d? | 977d | 0d | finish no earlier than 2004-07-30 | 刘怀民 |
| 124 | 1.2.2.9.3 | Support system | 89d? | 2004-08-02 | 2004-12-02 | 123 | 2004-07-01 | 2004-07-30 | 22d? | 977d |  | finish no earlier than 2004-11-30 | 刘怀民 |
| 125 | 1.2.2.9.4 | Field Map | 65d? | 2004-12-31 | 2005-03-31 |  | 2004-07-01 | 2004-07-30 | 22d? | 892d |  | finish no earlier than 2005-03-31 | 刘怀民 |

| ID | WBS | Task | Duration | Start | Finish | Predecessors | Complete | Remaining | Baseline start | Baseline finish | Baseline duration | Total slack | Free slack | Constraint | Text1 |
| --- | --- | --- | --- | --- | --- | --- | --- | --- | --- | --- | --- | --- | --- | --- | --- |
| 126 | 1.2.2.10 | **MC Truth Data** | 188d? | 2004-06-11 | 2005-03-01 |  |  |  | 2004-06-01 | 2004-11-01 | 110d? | 914d |  |  |  |
| 127 | 1.2.2.10.1 | MC Truth Data Format | 101d? | 2004-06-11 | 2004-10-31 |  |  |  | 2004-06-15 | 2004-07-15 | 23d? | 1001d |  | finish no earlier than 2004-10-31 | 邓子艳 |
| 128 | 1.2.2.10.2 | MC Truth Information | 90d? | 2004-06-28 | 2004-10-31 |  |  |  | 2004-07-01 | 2004-07-30 | 22d? | 914d | 0d | finish no earlier than 2004-10-31 | 邓子艳 |
| 129 | 1.2.2.10.3 | Data I/O | 87d? | 2004-11-01 | 2005-03-01 | 128 |  |  | 2004-07-01 | 2004-07-30 | 22d? | 914d |  | finish no earlier than 2005-02-28 | 邓子艳 |
| 130 | 1.2.2.11 | **Data I/O, Database and Persistency** | 397d? | 2004-02-02 | 2005-08-09 |  |  |  | 2004-06-01 | 2004-11-01 | 110d? | 799d |  |  |  |
| 131 | 1.2.2.11.1 | Data I/O for All Kinds | 397d? | 2004-02-02 | 2005-08-09 |  |  |  | 2004-06-15 | 2004-07-15 | 23d? | 799d |  | start no earlier than 2004-02-01 | 邓子艳 |
| 132 | 1.2.2.11.2 | Database for Common Data | 224d? | 2004-02-24 | 2004-12-31 |  |  |  | 2004-07-01 | 2004-07-30 | 22d? | 956d |  | finish no earlier than 2004-12-31 | 袁野 |
| 133 | 1.2.2.11.3 | Persistency with ROOT I/O | 177d? | 2004-06-25 | 2005-02-28 |  |  |  | 2004-07-01 | 2004-07-30 | 22d? | 915d |  | finish no earlier than 2005-02-28 | 北大 |
| 134 | 1.2.2.12 | **User Interface** | 401d? | 2004-07-28 A | 2006-02-08 |  | 8% | 369.92d? | 2004-06-01 | 2004-12-31 | 154d? | 668d |  |  |  |
| 135 | 1.2.2.12.1 | User Control System | 178d? | 2005-06-06 | 2006-02-08 | 137 |  |  | 2004-06-01 | 2004-06-30 | 22d? | 668d |  | finish no earlier than 2005-03-31 | 邓子艳 |
| 136 | 1.2.2.12.2 | Interactive/Batch Jobs, Visuliazation | 113d? | 2004-07-28 | 2004-12-31 |  |  |  | 2004-06-01 | 2004-06-30 | 22d? | 956d |  | finish no earlier than 2004-12-31 | 邓子艳 |
| 137 | 1.2.2.12.3 | Utilities, Shell Scipts | 220d? | 2004-08-01 A | 2005-06-03 |  | 18% | 180.4d? | 2004-06-01 | 2004-07-30 | 44d? | 668d | 0d | finish no earlier than 2005-05-30 | 刘怀民 |
| 138 | 1.2.2.13 | **Physics Validation** | 935d? | 2005-02-01 | 2008-09-01 |  |  |  | 2004-07-01 | 2005-06-30 | 261d? | 0d |  |  |  |
| 139 | 1.2.2.13.1 | Hadronic Simulation Models | 86d? | 2005-02-01 | 2005-05-31 |  |  |  | 2004-07-01 | 2004-09-30 | 66d? | 849d |  | finish no earlier than 2005-05-31 | 刘怀民 |
| 140 | 1.2.2.13.2 | Geant Cuts | 86d? | 2005-02-01 | 2005-05-31 |  |  |  | 2004-09-01 | 2004-12-31 | 88d? | 0d |  | finish no earlier than 2005-05-31 | 邓子艳 |
| 141 | 1.2.2.13.3 | Mass Production | 89d? | 2005-06-01 | 2005-10-03 | 140 |  |  | 2005-01-03 | 2005-06-30 | 129d? | 0d |  | finish no earlier than 2005-09-30 | 邓子艳 |
| 142 | 1.2.2.13.4 | Comaprisons with Data | 760d? | 2005-10-04 | 2008-09-01 | 141 |  |  | 2005-01-03 | 2005-06-30 | 129d? | 0d |  | finish no earlier than 2008-08-31 | 集体 |
| 143 | 1.2.3 | **Database and Calibration Software** | 742d? | 2003-06-02 A | 2006-04-04 |  | 10% | 671.23d? | 2003-06-02 | 2003-06-02 | 1d? | 629d |  |  | 邱进发 |
| 144 | 1.2.3.1 | **Infrastructure** | 365d | 2004-06-01 | 2005-10-24 |  |  |  | 2003-06-02 | 2003-06-02 | 1d? | 745d |  |  | 邱进发 |
| 145 | 1.2.3.1.1 | BES-III Infrastructure with Gaudi | 365d | 2004-06-01 | 2005-10-24 |  |  |  |  |  |  | 745d |  |  | 邱进发/马秋梅 |
| 146 | 1.2.3.2 | **Sub-detector calibration** | 365d? | 2004-06-01 | 2005-10-24 |  |  |  | 2003-06-02 | 2003-06-02 | 1d? | 745d |  |  |  |
| 147 | 1.2.3.2.1 | **Main Dirft Chamber** | 1d? | 2004-06-01 | 2004-06-01 |  |  |  | 2003-06-02 | 2003-06-02 | 1d? | 1109d |  |  |  |
| 148 | 1.2.3.2.1.1 | T0 calibration | 1d? | 2004-06-01 | 2004-06-01 |  |  |  |  |  |  | 1109d |  |  | 邱进发/伍灵慧 |
| 149 | 1.2.3.2.1.2 | dE/dx calibration | 1d? | 2004-06-01 | 2004-06-01 |  |  |  |  |  |  | 1109d |  |  | 王大勇 |
| 150 | 1.2.3.2.2 | Showe Counter | 365d | 2004-06-01 | 2005-10-24 |  |  |  |  |  |  | 745d |  |  | 王喆 |
| 151 | 1.2.3.2.3 | Time of Flight | 365d | 2004-06-01 | 2005-10-24 |  |  |  |  |  |  | 745d |  |  | 蒋林力 |
| 152 | 1.2.3.2.4 | Muon Counter | 365d? | 2004-06-01 | 2005-10-24 |  |  |  |  |  |  | 745d |  |  | 谢宇广 |

| ID | WBS | Task | Duration | Start | Finish | Complete | Remaining | Total slack | Constraint | Text1 |
| --- | --- | --- | --- | --- | --- | --- | --- | --- | --- | --- |
| 153 | 1.2.3.3 | **Database** | 742d | 2003-06-02 A | 2006-04-04 | 19% | 599.24d | 629d |  | 邱进发 |
| 154 | 1.2.3.3.1 | Database Design | 365d | 2003-06-02 A | 2004-10-22 | 38% | 226.76d | 1006d |  | 邱进发/马秋梅 |
| 155 | 1.2.3.3.2 | **Data Management Services & Servers** | 480d | 2004-06-02 A | 2006-04-04 | 13% | 418.1d | 629d |  | 马秋梅 |
| 156 | 1.2.3.3.2.1 | **Operation Support** | 480d | 2004-06-02 A | 2006-04-04 | 27% | 349.89d | 629d |  |  |
| 157 | 1.2.3.3.2.1.1 | MySQL/MySQL++ package/server configuration, deployment, and performance tuning | 24mo | 2004-06-02 A | 2006-04-04 | 29% | 17.09mo | 629d |  |  |
| 158 | 1.2.3.3.2.1.2 | Scalability and performance testing and optimization | 6w | 2004-06-02 | 2004-07-13 |  |  | 1079d | start no earlier than 2004-06-02 |  |
| 159 | 1.2.3.3.2.2 | **Database Administration** | 320d | 2004-06-02 | 2005-08-23 |  |  | 789d |  |  |
| 160 | 1.2.3.3.2.2.1 | Database backup and recovery procedures | 4w | 2004-06-02 | 2004-06-29 |  |  | 1089d | start no earlier than 2004-06-02 |  |
| 161 | 1.2.3.3.2.2.2 | Database Administration for data challenges | 16mo | 2004-06-02 | 2005-08-23 |  |  | 789d | start no earlier than 2004-06-02 |  |
| 162 | 1.2.3.3.2.2.3 | BES-III database browsers | 222d | 2004-06-02 | 2005-04-07 |  |  | 887d | start no earlier than 2004-06-02 |  |
| 163 | 1.2.4 | **Reconstruction** | 802d? | 2003-05-05 A | 2006-05-30 | 34% | 531.61d? | 589d |  | 毛泽普 |
| 164 | 1.2.4.1 | **MDC tracking** | 776d? | 2003-06-10 A | 2006-05-30 | 3% | 751.33d? | 589d |  | 毛泽普 |
| 165 | 1.2.4.1.1 | **fastrk** | 65d? | 2004-06-03 | 2004-09-01 |  |  | 1043d |  | 张晓梅 |
| 166 | 1.2.4.1.1.1 | MDC-Geo | 6d? | 2004-06-03 | 2004-06-10 |  |  | 1102d | finish no earlier than 2004-06-10 | 张晓梅 |
| 167 | 1.2.4.1.1.2 | raw data unpacking | 9d? | 2004-06-03 | 2004-06-15 |  |  | 1099d | start no earlier than 2004-06-03 | 张晓梅 |
| 168 | 1.2.4.1.1.3 | segment finding | 22d? | 2004-06-03 | 2004-07-02 |  |  | 1086d | start no earlier than 2004-06-03 | 张晓梅 |
| 169 | 1.2.4.1.1.4 | circle fitting 2D | 44d? | 2004-06-03 | 2004-08-03 |  |  | 1064d | start no earlier than 2004-06-03 | 张晓梅 |
| 170 | 1.2.4.1.1.5 | track fitting 3D | 63d | 2004-06-07 | 2004-09-01 |  |  | 1043d | finish no earlier than 2004-09-01 | 张晓梅 |
| 171 | 1.2.4.1.2 | **evtime** | 211d? | 2004-05-10 | 2005-02-28 |  |  | 915d |  | 腾涛/马想 |
| 172 | 1.2.4.1.2.1 | Tof-data unpacking and simple Calibration | 17d? | 2004-05-10 | 2004-06-01 |  |  | 1109d | finish no earlier than 2004-06-01 | 腾涛 |
| 173 | 1.2.4.1.2.2 | MDC-data unpacking and simple Calibration | 30d? | 2004-05-10 | 2004-06-18 |  |  | 1096d | finish no earlier than 2004-06-18 | 腾涛 |
| 174 | 1.2.4.1.2.3 | Event-t0 by TOF | 74d? | 2004-06-21 | 2004-09-30 |  |  | 1022d | finish no earlier than 2004-09-30 | 腾涛 |
| 175 | 1.2.4.1.2.4 | Event-t0 by MDC | 106d? | 2004-10-04 | 2005-02-28 |  |  | 915d | finish no earlier than 2005-02-28 | 马想 |
| 176 | 1.2.4.1.3 | **mdctrack** | 369d? | 2003-07-02 A | 2004-11-29 | 18% | 301.62d? | 980d |  | 臧石磊 |
| 177 | 1.2.4.1.3.1 | System study and design | 154d? | 2003-07-02 | 2004-02-02 |  |  | 1195d | finish no earlier than 2004-02-02 | 臧石磊 |
| 178 | 1.2.4.1.3.2 | MDCgeo | 21d? | 2004-02-03 | 2004-03-02 |  |  | 1174d | finish no earlier than 2004-03-02 | 臧石磊 |
| 179 | 1.2.4.1.3.3 | Raw-data unpacking | 20d | 2004-03-02 | 2004-03-29 |  |  | 1155d | start no earlier than 2004-03-02 | 臧石磊 |
| 180 | 1.2.4.1.3.4 | Segment finding and LR ambiguity | 18d | 2004-04-02 | 2004-04-27 |  |  | 1134d | start no earlier than 2004-04-02 | 臧石磊 |
| 181 | 1.2.4.1.3.5 | Segment linking and fitting | 45d? | 2004-05-03 | 2004-07-02 |  |  | 1086d | finish no earlier than 2004-07-02 | 臧石磊 |
| 182 | 1.2.4.1.3.6 | Track circle(2D track) | 86d | 2004-05-03 A | 2004-08-30 A | 100% |  |  | finish no earlier than 2003-06-27 | 臧石磊 |
| 183 | 1.2.4.1.3.7 | Z-tracking search | 21d? | 2004-09-01 | 2004-09-29 |  |  | 1023d | finish no earlier than 2004-09-29 | 臧石磊 |
| 184 | 1.2.4.1.3.8 | z-tracking and fitting (put z cut) | 42d? | 2004-09-02 | 2004-10-29 |  |  | 1001d | start no earlier than 2004-09-02 | 臧石磊 |
| 185 | 1.2.4.1.3.9 | Helix fitting | 64d? | 2004-09-01 | 2004-11-29 |  |  | 980d | finish no earlier than 2004-11-29 | 臧石磊 |

| ID | WBS | Task | Duration | Start | Finish | Total slack | Constraint | Text1 |
| --- | --- | --- | --- | --- | --- | --- | --- | --- |
| 186 | 1.2.4.1.4 | **mdc tracking based on Babar software** | 538d? | 2003-06-10 | 2005-06-30 | 827d |  | 山大 |
| 187 | 1.2.4.1.4.1 | Segment finding and LR ambiguity | 26d | 2004-08-06 | 2004-09-10 | 1036d | finish no earlier than 2004-09-10 | 山大 |
| 188 | 1.2.4.1.4.2 | Segment linking and fitting | 22d? | 2004-09-01 | 2004-09-30 | 1022d | finish no earlier than 2004-09-30 | 山大 |
| 189 | 1.2.4.1.4.3 | Track circle(2D track) | 14d | 2003-06-10 | 2003-06-27 | 1351d | finish no earlier than 2003-06-27 | 山大 |
| 190 | 1.2.4.1.4.4 | Z-tracking search | 51d? | 2004-10-21 | 2004-12-30 | 957d | finish no earlier than 2004-12-30 | 山大 |
| 191 | 1.2.4.1.4.5 | z-tracking and fitting | 63d? | 2005-01-03 | 2005-03-30 | 893d | finish no earlier than 2005-03-30 | 山大 |
| 192 | 1.2.4.1.4.6 | Helix fitting | 65d? | 2005-04-01 | 2005-06-30 | 827d | finish no earlier than 2005-06-30 | 山大 |
| 193 | 1.2.4.1.5 | **trkfit(KalMan filter and price correction)** | 519d? | 2004-06-03 | 2006-05-30 | 589d |  | 王大勇 马想 |
| 194 | 1.2.4.1.5.1 | System study and design | 67d? | 2004-06-03 | 2004-09-03 | 1041d | finish no earlier than 2004-09-03 | 王大勇 |
| 195 | 1.2.4.1.5.2 | correction of non uniform magnetic field | 21d? | 2004-09-03 | 2004-10-01 | 1021d | finish no earlier than 2004-10-01 | 王大勇 马想 |
| 196 | 1.2.4.1.5.3 | correction of energy loss | 23d? | 2004-09-01 | 2004-10-01 | 1021d | finish no earlier than 2004-10-01 | 王大勇 马想 |
| 197 | 1.2.4.1.5.4 | correction of multiple scattering | 22d? | 2004-10-01 | 2004-11-01 | 1000d | finish no earlier than 2004-11-01 | 王大勇 马想 |
| 198 | 1.2.4.1.5.5 | correction of particle fly | 23d? | 2004-11-01 | 2004-12-01 | 978d | finish no earlier than 2004-12-01 | 王大勇 马想 |
| 199 | 1.2.4.1.5.6 | correction of gravitational sag of wire | 24d? | 2005-01-03 | 2005-02-03 | 932d | finish no earlier than 2005-02-03 | 王大勇 马想 |
| 200 | 1.2.4.1.5.7 | correction of sigma with a function of position | 22d? | 2005-02-02 | 2005-03-03 | 912d | start no earlier than 2005-02-02 | 王大勇 马想 |
| 201 | 1.2.4.1.5.8 | correction of non uniform magnetic field | 21d? | 2004-09-03 | 2004-10-01 | 1021d | finish no earlier than 2004-10-01 | 马想 |
| 202 | 1.2.4.1.5.9 | Kalman fulter and pattern study | 282d? | 2005-05-02 | 2006-05-30 | 589d | finish no earlier than 2006-05-30 | 马想 |
| 203 | 1.2.4.1.6 | **track extrapolation** | 216d? | 2004-09-02 | 2005-06-30 | 827d |  | 马想 |
| 204 | 1.2.4.1.6.1 | System study and design | 64d? | 2004-09-02 | 2004-11-30 | 979d | finish no earlier than 2004-11-30 | 马想 |
| 205 | 1.2.4.1.6.2 | MDC to EMC | 42d? | 2004-12-02 | 2005-01-28 | 936d | finish no earlier than 2005-01-28 | 马想 |
| 206 | 1.2.4.1.6.3 | MDC to TOF | 41d? | 2005-02-02 | 2005-03-30 | 893d | finish no earlier than 2005-03-30 | 马想 |
| 207 | 1.2.4.1.6.4 | MDC to MU | 41d? | 2005-04-04 | 2005-05-30 | 850d | finish no earlier than 2005-05-30 | 马想 |
| 208 | 1.2.4.1.6.5 | EMC to MU | 21d? | 2005-06-02 | 2005-06-30 | 827d | finish no earlier than 2005-06-30 | 马想 |
| 209 | 1.2.4.1.6.6 | EMC to TOF | 21d? | 2005-06-02 | 2005-06-30 | 827d | finish no earlier than 2005-06-30 | 马想 |

| ID | WBS | Task | Duration | Start | Finish | Total slack | Constraint | Text1 |
| --- | --- | --- | --- | --- | --- | --- | --- | --- |
| 210 | 1.2.4.1.7 | **dE/dx** | 607d? | 2004-01-01 | 2006-04-28 | 611d |  | 王大勇 |
| 211 | 1.2.4.1.7.1 | dE/dx package | 197d? | 2004-01-01 | 2004-10-01 | 1021d | finish no earlier than 2004-10-01 | 王大勇 |
| 212 | 1.2.4.1.7.2 | dE/dx Cal. Method research | 345d? | 2005-01-03 | 2006-04-28 | 611d | finish no earlier than 2006-04-28 | 王大勇 |
| 213 | 1.2.4.1.7.3 | dE/dx calibration codes study | 345d? | 2005-01-03 | 2006-04-28 | 611d | finish no earlier than 2006-04-28 | 王大勇 |
| 214 | 1.2.4.2 | **TOF Tracking** | 153d? | 2004-06-01 | 2004-12-30 | 957d |  | 蒋林立 |
| 215 | 1.2.4.2.1 | TOF GEO and raw unpacking | 23d? | 2004-06-01 | 2004-07-01 | 1087d | start no earlier than 2004-06-01 | 蒋林立 |
| 216 | 1.2.4.2.2 | **track finder** | 153d? | 2004-06-01 | 2004-12-30 | 957d |  | 蒋林立 |
| 217 | 1.2.4.2.2.1 | hits selection | 23d? | 2004-08-02 | 2004-09-01 | 1043d | start no earlier than 2004-08-02 | 蒋林立 |
| 218 | 1.2.4.2.2.2 | tracking and track matching with MDC and EMC | 109d? | 2004-06-01 | 2004-10-29 | 1001d | finish no earlier than 2004-10-29 | 蒋林立 |
| 219 | 1.2.4.2.2.3 | code test and particle ID | 44d? | 2004-11-01 | 2004-12-30 | 957d | finish no earlier than 2004-12-30 | 蒋林立 |
| 220 | 1.2.4.3 | **EMC clustering** | 368d? | 2004-01-05 | 2005-06-01 | 848d |  | 王喆 |
| 221 | 1.2.4.3.1 | EMC barrel Geo. | 85d? | 2004-01-05 | 2004-04-30 | 1131d | finish no earlier than 2004-04-30 | 王喆 |
| 222 | 1.2.4.3.2 | EMC Cluster finding | 109d? | 2004-01-05 | 2004-06-03 | 1107d | finish no earlier than 2004-06-03 | 王喆 |
| 223 | 1.2.4.3.3 | EMC shower candiates selection | 109d? | 2004-01-05 | 2004-06-03 | 1107d | finish no earlier than 2004-06-03 | 王喆 |
| 224 | 1.2.4.3.4 | EMC shower attribution calculation | 110d? | 2004-03-03 | 2004-08-03 | 1064d | start no earlier than 2004-03-03 | 王喆 |
| 225 | 1.2.4.3.5 | EMC & MDC track matching | 23d? | 2004-11-03 | 2004-12-03 | 976d | finish no earlier than 2004-12-03 | 王喆 |
| 226 | 1.2.4.3.6 | EMC clustering system transfer to BOSS | 67d? | 2004-08-03 | 2004-11-03 | 998d | finish no earlier than 2004-11-03 | 王喆 |
| 227 | 1.2.4.3.7 | EndCap Geo. | 43d? | 2004-08-02 | 2004-09-29 | 1023d | start no earlier than 2004-08-02 | 王喆 |
| 228 | 1.2.4.3.8 | **Gamma correction** | 132d? | 2004-06-01 | 2004-12-01 | 978d |  |  |
| 229 | 1.2.4.3.8.1 | position correction | 132d? | 2004-06-01 | 2004-12-01 | 978d | start no earlier than 2004-06-01 |  |
| 230 | 1.2.4.3.8.2 | energy correction | 132d? | 2004-06-01 | 2004-12-01 | 978d | start no earlier than 2004-06-01 |  |
| 231 | 1.2.4.3.9 | **PI0 correction** | 131d? | 2004-12-01 | 2005-06-01 | 848d |  | 王喆 |
| 232 | 1.2.4.3.9.1 | position correction | 131d? | 2004-12-01 | 2005-06-01 | 848d | start no earlier than 2004-12-01 | 王喆 |
| 233 | 1.2.4.3.9.2 | energy correction | 131d? | 2004-12-01 | 2005-06-01 | 848d | finish no earlier than 2005-06-01 | 王喆 |

| ID | WBS | Task | Duration | Start | Finish | Complete | Total slack | Constraint | Text1 |
| --- | --- | --- | --- | --- | --- | --- | --- | --- | --- |
| 234 | 1.2.4.4 | **MU Tracking** | 609d? | 2003-05-05 | 2005-09-01 |  | 782d |  | 北大 |
| 235 | 1.2.4.4.1 | First reconstruction algorithm | 370d? | 2003-05-05 | 2004-10-01 |  | 1021d | start no earlier than 2003-05-05 | 北大 |
| 236 | 1.2.4.4.2 | track fitting research and track matching | 152d? | 2004-06-01 | 2004-12-29 |  | 958d | start no earlier than 2004-06-01 | 北大 |
| 237 | 1.2.4.4.3 | particle identification | 152d? | 2004-06-01 | 2004-12-29 |  | 958d | start no earlier than 2004-06-01 | 北大 |
| 238 | 1.2.4.4.4 | database relations research | 132d? | 2004-06-29 | 2004-12-29 |  | 958d | start no earlier than 2004-06-29 | 北大 |
| 239 | 1.2.4.4.5 | New reconstruction algorithm research | 262d? | 2004-09-01 | 2005-09-01 |  | 782d | finish no earlier than 2005-09-01 | 北大 |
| 240 | 1.2.4.5 | Event Reconstruction | 262d? | 2004-09-01 | 2005-09-01 |  | 782d | finish no earlier than 2005-09-01 | 冒亚军 |
| 241 | 1.2.4.6 | **Event Rec. System Testing** | 367d? | 2005-01-01 A | 2006-05-30 A | 100% |  |  | 毛泽普 |
| 242 | 1.2.4.6.1 | Framework System Cop. | 367d? | 2005-01-01 A | 2006-05-30 A | 100% |  |  | 李卫东 |
| 243 | 1.2.4.6.2 | MC System Cop. | 367d? | 2005-01-01 A | 2006-05-30 A | 100% |  |  | 刘怀民 |
| 244 | 1.2.4.6.3 | Cal. System Cop. | 367d? | 2005-01-01 A | 2006-05-30 A | 100% |  |  | 邱进发 |
| 245 | 1.2.4.6.4 | MDC Track System | 367d? | 2005-01-01 A | 2006-05-30 A | 100% |  |  | 臧石磊王大勇马想 |
| 246 | 1.2.4.6.5 | EMC System | 367d? | 2005-01-01 A | 2006-05-30 A | 100% |  |  |  |
| 247 | 1.2.4.6.6 | TOF System | 367d? | 2005-01-01 A | 2006-05-30 A | 100% |  |  | 科大 |
| 248 | 1.2.4.6.7 | MU Track System | 367d? | 2005-01-01 A | 2006-05-30 A | 100% |  |  | 北大 |
| 249 | 1.2.5 | **Event Filter Software** | 390d? | 2005-01-03 A | 2006-06-30 A | 100% |  |  |  |
| 250 | 1.2.5.1 | Interface with on-line data flow | 64d? | 2005-01-03 A | 2005-03-31 A | 100% |  | finish no earlier than 2004-06-14 | 李卫东 |
| 251 | 1.2.5.2 | Steering and control | 65d? | 2005-04-01 A | 2005-06-30 A | 100% |  | finish no earlier than 2004-06-14 |  |
| 252 | 1.2.5.3 | Algorithm study and development | 131d? | 2005-07-01 A | 2005-12-30 A | 100% |  | finish no earlier than 2004-06-14 |  |
| 253 | 1.2.5.4 | Testing in online environment | 130d? | 2006-01-02 A | 2006-06-30 A | 100% |  | finish no earlier than 2004-06-14 |  |
| 254 | 1.2.6 | Software Configuration Management | 782d? | 2004-01-01 A | 2006-12-29 A | 100% |  |  | 马秋梅 |
